# Sample Project Portfolio using MS Project

Schedule from MS Project, 1990-04-30 to 2003-05-26, costs in $.
PMOUSA Network

## Calendars

- Standard: Mon-Fri 08:00-12:00, 13:00-17:00; Sat-Sun off.

## Resources

| Resource |
| --- |
| prExternalID |

## Schedule

| ID | WBS | Task | Duration | Start | Finish | Baseline start | Baseline finish | Baseline duration | Total slack | Constraint | Cost | Text1 | Text2 | Text3 | Text6 | Text7 | Text14 | Text19 | Text20 | Text10 |
| --- | --- | --- | --- | --- | --- | --- | --- | --- | --- | --- | --- | --- | --- | --- | --- | --- | --- | --- | --- | --- |
| 1 | 1 | **1999 IT Project Portfolio** | 3411d | 1990-04-30 | 2003-05-26 |  |  |  | 0d |  | 31,277,519.14 |  |  |  |  |  |  |  |  |  |
| 2 | 1.1 | **1999 Open Projects** | 3411d | 1990-04-30 | 2003-05-26 |  |  |  | 0d |  | 27,450,847.27 |  |  |  |  |  |  |  |  |  |
| 3 | 1.1.1 | **Y2K** | 366d | 1998-10-07 | 2000-03-01 |  |  |  | 843d |  | 2,229,100.8 |  |  |  |  |  |  |  |  |  |
| 4 | 1.1.1.1 | Y2K Network Testing | 121d | 1999-04-05 | 1999-09-20 | 1999-04-05 | 1999-08-13 | 0d | 960d | start no earlier than 1999-04-05 | 101,909 | IT | Jonny Carson | Roger Bishop | Open | Y2K0023 | 15 | P-Major | med |  |
| 5 | 1.1.1.2 | Work Comp Print | 239d | 1998-10-21 | 1999-09-20 | 1998-10-21 | 1999-08-30 | 0d | 960d | start no earlier than 1998-10-21 | 26,479.9 | IT | Wyette Runyan | Carol Lucy | Open | Y2K0013 | 15 | P-Major | large | 1.1 |
| 6 | 1.1.1.3 | Y2K PC | 42d | 1999-07-23 | 1999-09-20 | 1999-07-23 | 1999-09-09 | 0d | 960d | start no earlier than 1999-07-23 | 3,762 | IT | Jonny Carson | Roger Bishop | Open | Y2K0027 | 15 | P-Major | small | 1.2 |
| 7 | 1.1.1.4 | Y2K Enterprise Test | 45d | 1999-08-02 | 1999-10-01 | 1999-08-02 | 1999-10-01 | 0d | 951d | start no earlier than 1999-08-02 | 31,860 | IT | Mike Damon | Roger Bishop | Open | Y2K0031 | 15 | P-Major | small | 1.3 |
| 8 | 1.1.1.5 | Y2K Upgrade SAA Gateway | 218d | 1998-12-02 | 1999-10-01 | 1998-12-02 | 1999-07-01 | 0d | 951d | start no earlier than 1998-12-02 | 10,395 | IT | Kelly Witte |  | Open | Y2K0003 | 15 | P-Major | large | 1.4 |
| 9 | 1.1.1.6 | Y2K Disaster Recovery Drill | 77d | 1999-07-01 | 1999-10-15 | 1999-07-01 | 1999-10-15 | 0d | 941d | start no earlier than 1999-07-01 | 13,009.7 | IT | Mike Damon | Robert Vega | Open | Y2K0028 | 15 | P-Major | med | 1.5 |
| 10 | 1.1.1.7 | Y2K Montana Project | 271d | 1998-10-19 | 1999-11-01 | 1998-10-19 | 1999-04-30 | 0d | 930d | start no earlier than 1998-10-19 | 752,527.25 | IT | Nancy Craig | Roger Bishop | Open | Y2K0017 | 15 | P-Major | large | 1.6 |
| 11 | 1.1.1.8 | Y2K Phase VI (PMS) | 256d | 1998-12-14 | 1999-12-06 | 1998-12-14 | 1999-12-06 | 0d | 905d | start no earlier than 1998-12-14 | 125,866 | IT | Mike Damon | Paul Strofus | Open | Y2K0024 | 15 | P-Major | large | 1.7 |
| 12 | 1.1.1.9 | Y2K Contingency Plan | 201d | 1999-03-22 | 1999-12-27 | 1999-03-22 | 1999-12-27 | 0d | 890d | start no earlier than 1999-03-22 | 181,773.25 | IT | Mick Mathias | Luke Smith | Open | Y2K0001 | 15 | P-Major | large | 1.8 |
| 13 | 1.1.1.10 | Y2K Project Management | 324d | 1998-10-07 | 2000-01-03 | 1998-10-07 | 1999-12-31 | 0d | 885d | start no earlier than 1998-10-07 | 677,440.7 | IT | Mike Damon | Roger Bishop | Open | Y2K0015 | 15 | P-Major | large | 1.9 |
| 14 | 1.1.1.11 | Risk Intelligence\ABC Risk Pro | 306d | 1998-11-30 | 2000-01-31 | 1998-11-30 | 1999-12-31 | 0d | 865d | start no earlier than 1998-11-30 | 197,127 | IT | Char Valley | David Stewart | Open | Y2K0016 | 15 | P-Maintenance | large | 1.10 |
| 15 | 1.1.1.12 | Y2K Rework | 158d | 1999-07-26 | 2000-03-01 | 1999-07-26 | 2000-03-01 | 0d | 843d | start no earlier than 1999-07-26 | 106,951 | IT | Mike Damon | Roger Bishop | Open | Y2K0030 | 15 | P-Major | large | 1.11 |
| 17 | 1.1.2 | **SAP** | 421d | 1998-11-09 | 2000-06-19 |  |  |  | 765d |  | 2,384,262.9 |  |  |  |  |  |  |  |  |  |
| 18 | 1.1.2.1 | Work Comp Phase 4 | 263d | 1999-04-19 | 2000-04-19 | 1999-04-19 | 2000-03-15 | 0d | 808d | start no earlier than 1999-04-19 | 407,722.6 | P&C | Skip Janis | Carol Lucy | Open | SAP0005 | 23 | P-Major | large |  |
| 19 | 1.1.2.2 | Billing - SAP | 389d | 1998-11-09 | 2000-05-04 | 1998-11-09 | 2000-05-11 | 0d | 797d | start no earlier than 1998-11-09 | 426,969 | Accounti | Bill Mason | Luke Boehmer | Open | SAP0002 | 23 | P-Major | large | 2.1 |
| 20 | 1.1.2.3 | Financials - SAP | 421d | 1998-11-09 | 2000-06-19 | 1998-11-09 | 2000-06-19 | 0d | 765d | start no earlier than 1998-11-09 | 1,549,571.3 | Accounti | Laurie Cantu | Bill Lewis | Open | SAP0003 | 23 | P-Major | large | 2.2 |
| 22 | 1.1.3 | **Atlantis** | 886d | 1997-02-24 | 2000-07-17 |  |  |  | 745d |  | 5,978,006.45 |  |  |  |  |  |  |  |  |  |
| 23 | 1.1.3.1 | Remote Access | 320d | 1998-06-08 | 1999-08-27 | 1998-06-08 | 1999-05-10 | 0d | 976d | start no earlier than 1998-06-08 | 64,111.5 | ASMPS | Jay Flatner | Ryan McAndrews | Open | CPC0002 | 23 | P-Infrastructure | large |  |
| 24 | 1.1.3.2 | Atlantis Replication | 120d | 1999-07-12 | 1999-12-24 | 1999-07-12 | 1999-12-24 | 0d | 891d | start no earlier than 1999-07-12 | 138,747.5 | ASMPS | Bill McCrosky | Bill Whitney | Open | CPC0021 | 23 | P-Major | large | 3.1 |
| 25 | 1.1.3.3 | Atlantis-Test & Metrics | 176d | 1999-04-29 | 1999-12-30 | 1999-04-29 | 1999-11-02 | 0d | 887d | start no earlier than 1999-04-29 | 190,346.8 | ASMPS | Merlin Molson | Bill Whitney | Open | CPC0015 | 23 | P-Development | large | 3.2 |
| 26 | 1.1.3.4 | Atlantis Support Plan | 350d | 1998-08-31 | 1999-12-31 | 1998-08-31 | 1999-12-31 | 0d | 886d | start no earlier than 1998-08-31 | 1,262,524 | ASMPS | Troy Lister | Bill Whitney | Open | CPC0007 | 23 | P-Major | large | 3.3 |
| 27 | 1.1.3.5 | Integration Program Mgmt | 185d | 1999-04-19 | 1999-12-31 | 1999-04-19 | 1999-12-31 | 0d | 886d | start no earlier than 1999-04-19 | 1,249,944.7 | IT | Oscar Kaiser | Bill Thomas | Open | CPC0013 | 23 | P-Development | large | 3.4 |
| 28 | 1.1.3.6 | Atlantis Delivery Support | 293d | 1998-11-18 | 1999-12-31 | 1998-11-18 | 1999-12-31 | 0d | 886d | start no earlier than 1998-11-18 | 367,993.3 | ASMPS | Tom Schmidt | Bill Whitney | Open | CPC0010 | 23 | P-Major | large | 3.5 |
| 29 | 1.1.3.7 | Atlantis Development Managemen | 135d | 1999-06-28 | 1999-12-31 | 1999-06-28 | 1999-12-31 | 0d | 886d | start no earlier than 1999-06-28 | 212,639.6 | MPMPS | Dave Poultney | Bill Whitney | Open | CPC0017 | 23 | P-Major | large | 3.6 |
| 30 | 1.1.3.8 | ASM-Blvd | 290d | 1998-11-23 | 1999-12-31 | 1998-11-23 | 1999-12-31 | 0d | 886d | start no earlier than 1998-11-23 | 128,520 | ASMPS | Gary Matson | Bill Thomas | Open | CPC0001 | 23 | Minor | large | 3.7 |
| 31 | 1.1.3.9 | 1999 Quality Assurance | 260d | 1999-01-04 | 1999-12-31 |  |  |  | 886d | start no earlier than 1999-01-04 |  | IT | Barbara Nothan | Peter Smith | Open | CPC0011 | 23 | P-Support | large | 3.8 |
| 32 | 1.1.3.10 | OM&R V5 | 345d | 1998-10-01 | 2000-01-26 | 1998-10-01 | 1999-12-30 | 0d | 868d | start no earlier than 1998-10-01 | 359,683.02 | ASMPS | Neal Goodkind | Cathy Loveland | Open | CPC0016 | 23 | P-Development | large | 3.9 |
| 33 | 1.1.3.11 | ABC - Busn Transformation | 204d | 1999-04-19 | 2000-01-27 | 1999-04-19 | 2000-01-27 | 0d | 867d | start no earlier than 1999-04-19 | 831,101.3 | IT | Oscar Jones | Bill Whitney | Open | CPC0014 | 23 | P-Development | large | 3.10 |
| 34 | 1.1.3.12 | Atlantis SYSTEMS TEST | 513d | 1998-04-15 | 2000-03-31 |  |  |  | 821d | start no earlier than 1998-04-15 |  | ASMPS | Barbara Nothan | Bill Whitney | Open | CPC0009 | 23 | P-Major | large | 3.11 |
| 35 | 1.1.3.13 | Atlantis Interface & Conversio | 830d | 1997-02-24 | 2000-04-28 | 1997-02-24 | 2000-02-15 | 0d | 801d | start no earlier than 1997-02-24 | 797,668.73 | ASMPS | Gail Killroy | Bill Whitney | Open | CPC0008 | 23 | P-Major | large | 3.12 |
| 36 | 1.1.3.14 | Atlantis Deployment Plan | 270d | 1999-07-06 | 2000-07-17 | 1999-07-19 | 1999-11-22 | 0d | 745d | start no earlier than 1999-07-06 | 374,726 | ASMPS | Jeff Poppa | Bill Whitney | Open | CPC0023 | 23 | P-Major | med | 3.13 |

| ID | WBS | Task | Duration | Start | Finish | Baseline start | Baseline finish | Baseline duration | Total slack | Constraint | Cost | Text1 | Text2 | Text3 | Text6 | Text7 | Text14 | Text19 | Text20 | Text10 |
| --- | --- | --- | --- | --- | --- | --- | --- | --- | --- | --- | --- | --- | --- | --- | --- | --- | --- | --- | --- | --- |
| 38 | 1.1.4 | **Small** | 220d | 1999-03-01 | 1999-12-31 |  |  |  | 886d |  | 109,372.5 |  |  |  |  |  |  |  |  |  |
| 39 | 1.1.4.1 | Sm-Fin99-315 | 18d | 1999-09-13 | 1999-10-06 | 1999-09-13 | 1999-10-06 | 0d | 948d | start no earlier than 1999-09-13 | 4,667 | IT | Sherri Kansas | Teresa Jacklyn | Open | Small | 15 | Maintenance/Small | small |  |
| 40 | 1.1.4.2 | Sm-PAY99_011 | 18d | 1999-09-13 | 1999-10-06 | 1999-09-13 | 1999-10-06 | 0d | 948d | start no earlier than 1999-09-13 | 2,233 | Acct | Sherri Kansas | Teresa Jacklyn | Open | Small1 | 15 | Maintenance/Small | small |  |
| 41 | 1.1.4.3 | Sm-PAY99_013 | 26d | 1999-09-17 | 1999-10-22 | 1999-09-17 | 1999-10-22 | 0d | 936d | start no earlier than 1999-09-17 | 2,233 | Acct | Sherri Kansas | Teresa Jacklyn | Open | Small2 | 15 | Maintenance/Small | small |  |
| 42 | 1.1.4.4 | D-ASM Admin | 220d | 1999-03-01 | 1999-12-31 |  |  |  | 886d | start no earlier than 1999-03-01 |  | ASMPS | Tim Rodgers | Bill Beltsmith | Open | DASM | 15 | SM-Department | large |  |
| 43 | 1.1.4.5 | D-ASM Underw W | 1d | 1999-03-01 | 1999-03-01 |  |  |  | 1105d | start no earlier than 1999-03-01 |  | ASMPS | Tim Rodgers | Bill Beltsmith | Open | D054 | 15 | SM-Department |  |  |
| 44 | 1.1.4.6 | D-Audit Bus Grp | 146d | 1999-03-01 | 1999-09-20 | 1999-03-01 | 1999-07-08 | 0d | 960d | start no earlier than 1999-03-01 | 10,933 | Audit | Tim Rodgers | Bill Beltsmith | Open | DAU | 15 | SM-Department | med |  |
| 45 | 1.1.4.7 | D-Atlantis | 220d | 1999-03-01 | 1999-12-31 |  |  |  | 886d | start no earlier than 1999-03-01 |  | ASMPS | Tim Rodgers | Bill Beltsmith | Open | DCPCPS | 15 | SM-Department | large | 10 |
| 46 | 1.1.4.8 | D-Sponsor (ABC) | 134d | 1999-03-01 | 1999-09-02 | 1999-03-01 | 1999-07-02 | 0d | 972d | start no earlier than 1999-03-01 | 4,252 | Ins Dealer | Tim Rodgers | Bill Beltsmith | Open | DDU | 15 | SM-Department | med | 11 |
| 47 | 1.1.4.9 | D-IT | 220d | 1999-03-01 | 1999-12-31 | 1999-03-01 | 1999-09-08 | 0d | 886d | start no earlier than 1999-03-01 | 40,967.5 | IT | Judy Dodger | Bill Beltsmith | Open | DETS | 15 | SM-Department | med | 12 |
| 48 | 1.1.4.10 | D-F&I | 145d | 1999-03-01 | 1999-09-17 | 1999-03-01 | 1999-08-06 | 0d | 961d | start no earlier than 1999-03-01 | 8,975.5 | F&I | Tim Rodgers | Bill Beltsmith | Open | DVSC | 15 | SM-Department | med | 13 |
| 49 | 1.1.4.11 | D-Human Resources | 220d | 1999-03-01 | 1999-12-31 |  |  |  | 886d | start no earlier than 1999-03-01 |  | HR | Tim Rodgers | Bill Beltsmith | Open | D250 | 15 | SM-Department | large | 14 |
| 50 | 1.1.4.12 | D-Legal Department | 184d | 1999-03-01 | 1999-11-11 | 1999-09-01 | 1999-11-11 | 0d | 922d | start no earlier than 1999-03-01 | 21,276 | Legal | Tim Rodgers | Bill Beltsmith | Open | D310 | 15 | SM-Department | small | 15 |
| 51 | 1.1.4.13 | D-Salvage Department | 1d | 1999-03-01 | 1999-03-01 |  |  |  | 1105d | start no earlier than 1999-03-01 |  | Salvage | Tim Rodgers | Bill Beltsmith | Open | DSAL | 15 | SM-Department |  | 16 |
| 52 | 1.1.4.14 | Louisburg | 56d | 1999-08-05 | 1999-10-21 | 1999-08-05 | 1999-10-14 | 0d | 937d | start no earlier than 1999-08-05 | 13,835.5 | VSC | Lisa Doright | ShellyBuchannan | Open | ESC0009 | 15 | Small | small | 17 |
| 54 | 1.1.5 | **Open Proposals** | 149d | 1999-06-08 | 1999-12-31 |  |  |  | 886d |  | 30,186 |  |  |  |  |  |  |  |  |  |
| 55 | 1.1.5.1 | 141613-CDTrainingLab | 149d | 1999-06-08 | 1999-12-31 | 1999-06-08 | 1999-12-31 | 0d | 886d | start no earlier than 1999-06-08 | 6,642 | Corp Dev | Proposal | Bill Saunders | Open | PRP0001 | 20 | AP-Proposal | med | 19 |
| 56 | 1.1.5.2 | 145842-Move Alltel SW | 99d | 1999-08-17 | 1999-12-31 | 1999-08-17 | 1999-12-31 | 0d | 886d | start no earlier than 1999-08-17 | 6,642 | AC | Proposal | John Helter | Open | PRP0002 | 20 | AP-Proposal | med | 20 |
| 57 | 1.1.5.3 | 192626-Paradox Conversion Impact | 99d | 1999-08-17 | 1999-12-31 | 1999-08-17 | 1999-12-31 | 0d | 886d | start no earlier than 1999-08-17 | 6,642 | IT | Proposal | Deb Johnson | Open | PRP0003 | 18 | AP-Proposal | med | 21 |
| 58 | 1.1.5.4 | 090742-MIA Electronic Forms | 57d | 1999-09-14 | 1999-12-01 | 1999-09-17 | 1999-12-01 | 0d | 908d | start no earlier than 1999-09-14 | 2,700 | Serv | Proposal | Carole Elliott | Open | PRP0004 | 12 | AP-Proposal | med | 22 |
| 59 | 1.1.5.5 | 171055-Enterprise Readi Test Cnt | 15d | 1999-09-13 | 1999-10-01 | 1999-09-13 | 1999-10-01 | 0d | 951d | start no earlier than 1999-09-13 | 2,160 | IT | Proposal | Barb Tebbe | Open | PRP0005 | 12 | AP-Proposal | small | 23 |
| 60 | 1.1.5.6 | 123020-Facultative Reinsure | 45d | 1999-09-14 | 1999-11-15 | 1999-09-16 | 1999-11-15 | 0d | 920d | start no earlier than 1999-09-14 | 5,400 | Serv | Proposal | Jim Kirby | Open | PRP0006 | 10 | AP-Proposal | small | 24 |
| 62 | 1.1.6 | **Infrastructure** | 420d | 1998-08-10 | 2000-03-17 |  |  |  | 831d |  | 1,614,047.35 |  |  |  |  |  |  |  |  |  |
| 63 | 1.1.6.1 | MD: Manage Desktop Process- Pt 1 | 168d | 1999-05-17 | 2000-01-05 | 1999-05-17 | 2000-01-05 | 0d | 883d | start no earlier than 1999-05-17 | 229,238.5 | IT | Neil Giggnot | Keith Terry | Open | TCO0008 | 14 | P-Desktop | med | 25 |
| 64 | 1.1.6.2 | Lotus Notes Admin (HO) | 270d | 1998-12-21 | 1999-12-31 | 1998-12-21 | 1999-12-31 | 0d | 886d | start no earlier than 1998-12-21 | 101,556 | IT | Kelly Witte | Norm Arnmey | Open | DSK0023 | 14 | I-Infrastructure | large | 26 |
| 65 | 1.1.6.3 | Fox Pro Development | 275d | 1998-12-01 | 1999-12-20 | 1998-12-01 | 1999-12-20 | 0d | 895d | start no earlier than 1998-12-01 | 181,062 | F&I | Denise Ambian | Norm Arnmey | Open | ESC0004 | 14 | I-Infrastructure | large | 27 |
| 66 | 1.1.6.4 | Web-Hosting Architecture | 116d | 1999-04-12 | 1999-09-20 | 1999-04-12 | 1999-06-15 | 0d | 960d | start no earlier than 1999-04-12 | 12,237 | IT | Jay Flatner | Norm Arnmey | Open | ITN0003 | 14 | I-Infrastructure | small | 28 |
| 67 | 1.1.6.5 | IT Request Service, Final | 156d | 1999-02-12 | 1999-09-17 | 1999-02-12 | 1999-08-19 | 0d | 961d | start no earlier than 1999-02-12 | 16,830.35 | IT | Chris Hawkins | Norm Arnmey | Open | OPT0003 | 14 | I-Infrastructure | med | 29 |
| 68 | 1.1.6.6 | NOC Redesign Project | 230d | 1998-11-03 | 1999-09-20 | 1998-11-03 | 1999-08-02 | 0d | 960d | start no earlier than 1998-11-03 | 75,886 | IT | Kelly Witte | Norm Arnmey | Open | TCO0004 | 14 | I-Infrastructure | large | 30 |
| 69 | 1.1.6.7 | Thin Client Computing\Feasibilit | 121d | 1999-04-05 | 1999-09-20 | 1999-04-05 | 1999-09-17 | 0d | 960d | start no earlier than 1999-04-05 | 38,826.5 | IT | Jonny Carson | Lisa Barge | Open | TCC99 | 14 | Infrastructure | med | 31 |
| 70 | 1.1.6.8 | Boston Move | 66d | 1999-06-21 | 1999-09-20 | 1999-06-25 | 1999-09-08 | 0d | 960d | start no earlier than 1999-06-21 | 28,206 | Ins Dealer | Wayne Damon | Eisenberg | Open | ADM0014 | 14 | P-Infrastructure | med | 32 |
| 71 | 1.1.6.9 | Seattle Move | 62d | 1999-06-25 | 1999-09-20 | 1999-06-25 | 1999-09-08 | 0d | 960d | start no earlier than 1999-06-25 | 44,730.5 | Ins Dealer | Wayne Damon | Eisenberg | Open | ADM0015 | 14 | P-Infrastructure | med | 33 |
| 72 | 1.1.6.10 | Implement Project Office | 226d | 1999-02-19 | 1999-12-31 | 1999-02-19 | 1999-12-31 | 0d | 886d | start no earlier than 1999-02-19 | 199,147 | IT | Joe Taylor | Peter Smith | Open | CLN0005 | 16 | P-Infrastructure | large | 34 |
| 73 | 1.1.6.11 | ABC POEM | 69d | 1999-06-24 | 1999-09-28 | 1999-06-24 | 1999-09-28 | 0d | 954d | start no earlier than 1999-06-24 | 162,955 | IT | Joe Taylor | Peter Smith | Open | CLN0006 | 17 | P-Infrastructure | med | 35 |
| 74 | 1.1.6.12 | MD: MS SMS 2.0 Imp-Phase 1 | 228d | 1999-02-15 | 1999-12-29 | 1999-02-15 | 1999-12-29 | 0d | 888d | start no earlier than 1999-02-15 | 340,239.5 | IT | Neil Giggnot | Keith Terry | Open | DSK0020 | 15 | P-Infrastructure | large | 36 |
| 75 | 1.1.6.13 | ICAP Web Hosting | 211d | 1999-05-03 | 2000-02-21 | 1999-05-03 | 2000-01-07 | 0d | 850d | start no earlier than 1999-05-03 | 16,087 | F&I | Jay Flatner | Dennis O'Brien | Open | ITN0002 | 15 | P-Infrastructure | large | 37 |
| 76 | 1.1.6.14 | Claims Reorg - Phone | 164d | 1999-08-03 | 2000-03-17 | 1999-08-03 | 2000-03-17 | 0d | 831d | start no earlier than 1999-08-03 | 65,296.5 | Claims | Wayne Damon | Debi Doering | Open | PMW6 | 16 | P-Infrastructure | large | 38 |
| 77 | 1.1.6.15 | Corporate Internet Access | 386d | 1998-08-10 | 2000-01-31 | 1998-08-10 | 1999-10-13 | 0d | 865d | start no earlier than 1998-08-10 | 27,109.5 | IT | Jay Flatner | Russ Jackson | Open | VAL0002 | 15 | P-Infrastructure | large | 39 |
| 78 | 1.1.6.16 | Fax Server | 266d | 1998-09-14 | 1999-09-20 | 1998-09-14 | 1999-03-23 | 0d | 960d | start no earlier than 1998-09-14 | 74,640 | IT | Jonny Carson | Hollowell, Bruns, D. O'Brien | Open | VAL0003 | 15 | P-Infrastructure | large | 40 |

| ID | WBS | Task | Duration | Start | Finish | Baseline start | Baseline finish | Baseline duration | Total slack | Constraint | Cost | Text1 | Text2 | Text3 | Text6 | Text7 | Text10 | Text14 | Text19 | Text20 |
| --- | --- | --- | --- | --- | --- | --- | --- | --- | --- | --- | --- | --- | --- | --- | --- | --- | --- | --- | --- | --- |
| 80 | 1.1.7 | **Enhancements\Maintenance** | 2711d | 1990-04-30 | 2000-09-18 |  |  |  | 700d |  | 3,646,641.29 |  |  |  |  |  |  |  |  |  |
| 81 | 1.1.7.1 | Business Life | 239d | 1998-10-21 | 1999-09-20 | 1998-10-21 | 1999-04-05 | 0d | 960d | start no earlier than 1998-10-21 | 511,943 | P&C | Jackie Triple | Susan Blatt | Open | LIF0001 | 41 | 14 | P-Major | large |
| 82 | 1.1.7.2 | Occurrence/Loss Summary | 394d | 1998-04-01 | 1999-10-04 | 1998-04-01 | 1999-10-25 | 0d | 950d | start no earlier than 1998-04-01 | 298,369.05 | Claims | Lisa Doright | Cindy Jantti | Open | CMS0003 | 42 | 14 | P-Maintenance | large |
| 83 | 1.1.7.3 | Contract Renumbering - | 107d | 1999-07-09 | 1999-12-06 | 1999-07-09 | 1999-12-14 | 0d | 905d | start no earlier than 1999-07-09 | 59,109 | F&I | Lisa Doright | ShellyBuchannan | Open | ESC0006 | 43 | 14 | P-Maintenance | med |
| 84 | 1.1.7.4 | E Div. Laptop Deployment | 91d | 1999-05-17 | 1999-09-20 | 1999-05-17 | 1999-09-17 | 0d | 960d | start no earlier than 1999-05-17 | 78,003.75 | Ins Dealer | Jonny Carson | Deb Fitzgerald | Open | DLR0002 | 44 | 14 | Enhancements | med |
| 85 | 1.1.7.5 | PC WorkCenter | 290d | 1998-11-23 | 1999-12-31 | 1998-11-23 | 1999-12-31 | 0d | 886d | start no earlier than 1998-11-23 | 11,124 | Ins Dealer | Gary Matson | Steve Thomas | Open | DLR0003 | 45 | 14 | Enhancements | large |
| 86 | 1.1.7.6 | Old Life | 450d | 1997-12-30 | 1999-09-20 | 1998-12-23 | 1999-03-02 | 0d | 960d | start no earlier than 1997-12-30 | 6,120 | F&I | Jackie Triple | Steve Thomas | Open | LIF0003 | 46 | 14 | Enhancements | large |
| 87 | 1.1.7.7 | SAS Underwriting | 289d | 1998-11-24 | 1999-12-31 | 1998-11-24 | 1999-12-31 | 0d | 886d | start no earlier than 1998-11-24 | 11,340 | IT | Gary Matson | Steve Thomas | Open | SAS0001 | 47 | 14 | Enhancements | large |
| 88 | 1.1.7.8 | GIT99 | 182d | 1999-03-22 | 1999-11-30 | 1999-03-22 | 1999-11-30 | 0d | 909d | start no earlier than 1999-03-22 | 328,473.5 | IT | Shelly Sample | Jane Hunley | Open | UNI0003 | 48 | 14 | Enhancements | large |
| 89 | 1.1.7.9 | Credit Life Experience Stat | 67d | 1999-07-06 | 1999-10-06 |  |  |  | 948d | start no earlier than 1999-07-06 |  | F&I | Lisa Doright | ShellyBuchannan | Open | CAS0002 | 49 | 14 | Maintenance | med |
| 90 | 1.1.7.10 | RIP Misc Tasks | 276d | 1998-12-11 | 1999-12-31 | 1998-12-11 | 1999-12-31 | 0d | 886d | start no earlier than 1998-12-11 | 34,276.5 | IT |  | Mary English | Open | RPI0001 | 50 | 14 | Maintenance | large |
| 91 | 1.1.7.11 | Credit Life | 770d | 1997-01-21 | 2000-01-03 | 1998-05-18 | 1999-06-30 | 0d | 885d | start no earlier than 1997-01-21 | 52,686.5 | F&I | Jackie Triple | Susan Blatt | Open | CAS0001 | 51 | 14 | M-Maintenance | large |
| 92 | 1.1.7.12 | F & I ESC | 963d | 1996-04-24 | 1999-12-31 | 1998-11-30 | 1999-12-31 | 0d | 886d | start no earlier than 1996-04-24 | 230,593 | F&I | Jackie Triple | Susan Blatt | Open | ESC0001 | 52 | 14 | M-Maintenance | large |
| 93 | 1.1.7.13 | F&I Maintenance | 239d | 1998-10-21 | 1999-09-20 |  |  |  | 960d | start no earlier than 1998-10-21 |  | F&I | Jackie Triple | Susan Blatt | Open | ESC0003 | 53 | 14 | M-Maintenance | large |
| 94 | 1.1.7.14 | Life Accounting | 253d | 1997-01-13 | 1997-12-31 |  |  |  | 1408d | start no earlier than 1997-01-13 |  | F&I | Jackie Triple | Susan Blatt | Open | LIF0002 | 54 | 14 | M-Maintenance | large |
| 95 | 1.1.7.15 | AC | 410d | 1998-06-08 | 1999-12-31 | 1998-12-23 | 1999-12-31 | 0d | 886d | start no earlier than 1998-06-08 | 44,580 | AC | Jackie Triple | Susan Blatt | Open | UAC0001 | 55 | 14 | M-Maintenance | large |
| 96 | 1.1.7.16 | UniCover Maintenance | 466d | 1998-12-07 | 2000-09-18 |  |  |  | 700d | start no earlier than 1998-12-07 |  | IT | Wyette Runyan | Barry Morris | Open | UNI0001 | 56 | 14 | M-Maintenance | large |
| 97 | 1.1.7.17 | UniUMAP | 116d | 1999-04-12 | 1999-09-20 |  |  |  | 960d | start no earlier than 1999-04-12 |  | IT | Terri Hitter | Mary English | Open | UNI0004 | 57 | 14 | M-Maintenance | med |
| 98 | 1.1.7.18 | Work Comp Maintenance Plan | 236d | 1999-02-05 | 1999-12-31 |  |  |  | 886d | start no earlier than 1999-02-05 |  | IT | Wyette Runyan | Carol Kinkenberg | Open | WKC0001 | 58 | 14 | M-Maintenance | large |
| 99 | 1.1.7.19 | Access Claims System Backlo | 691d | 1997-05-09 | 1999-12-31 | 1997-05-09 | 1999-12-31 | 0d | 886d | start no earlier than 1997-05-09 | 1,106,994.55 | Claims | Betsy Highbrow | Mary English | Open | ACS9798 | 59 | 14 | M-Maintenance Backlog | large |
| 100 | 1.1.7.20 | CMS Backlog | 721d | 1997-03-28 | 1999-12-31 | 1997-03-28 | 1999-12-31 | 0d | 886d | start no earlier than 1997-03-28 | 71,184.38 | Claims | Betsy Highbrow | Mary English | Open | CMS0001 | 60 | 14 | M-Maintenance Backlog | large |
| 101 | 1.1.7.21 | Financial Backlog | 1337d | 1995-01-02 | 2000-02-15 | 1997-12-15 | 1999-12-31 | 0d | 854d | start no earlier than 1995-01-02 | 302,204 | Accounti | Pam Donot | Jack Swimming | Open | FIN0001 | 61 | 14 | M-Maintenance Backlog | large |
| 102 | 1.1.7.22 | INS Backlog | 2526d | 1990-04-30 | 2000-01-03 | 1997-12-30 | 2000-01-03 | 0d | 885d | start no earlier than 1990-04-30 | 253,004.49 | Accounti | Pam Donot | Jack Swimming | Open | INS0001 | 62 | 14 | M-Maintenance Backlog | large |
| 103 | 1.1.7.23 | PAYROLL Backlog | 645d | 1997-11-17 | 2000-05-05 | 1999-03-12 | 1999-09-30 | 0d | 796d | start no earlier than 1997-11-17 | 38,664 | IT | Pam Donot | Jack Swimming | Open | PAY0001 | 63 | 14 | M-Maintenance Backlog | large |
| 104 | 1.1.7.24 | PMS Backlog | 524d | 1997-12-30 | 1999-12-31 | 1998-02-13 | 1999-12-31 | 0d | 886d | start no earlier than 1997-12-30 | 88,559.98 | P&C | Betsy Highbrow | Jack Swimming | Open | PMS0001 | 64 | 14 | M-Maintenance Backlog | large |
| 105 | 1.1.7.25 | Statistics Backog | 2469d | 1990-07-17 | 1999-12-31 | 1997-07-24 | 1999-12-31 | 0d | 886d | start no earlier than 1990-07-17 | 119,411.59 | IT | Pam Donot | Jack Swimming | Open | STA0001 | 65 | 14 | M-Maintenance Backlog | large |

| ID | WBS | Task | Duration | Start | Finish | Total slack | Constraint | Text2 | Text6 | Text7 | Text10 | Text19 | Text20 | Text1 | Text3 |
| --- | --- | --- | --- | --- | --- | --- | --- | --- | --- | --- | --- | --- | --- | --- | --- |
| 107 | 1.1.8 | **Pending** | 1537d | 1994-02-10 | 1999-12-31 | 886d |  |  |  |  |  |  |  |  |  |
| 108 | 1.1.8.1 | Sponsor RSM Comp Report Fix | 1d | 1996-01-01 | 1996-01-01 | 1930d | finish no earlier than 1996-01-01 | Pam Donot | Pending | 469 | NA | Maintenance | NA |  |  |
| 109 | 1.1.8.2 | Fix Fira & FIS Adjustments-Type | 1d | 1996-01-01 | 1996-01-01 | 1930d | finish no earlier than 1996-01-01 | Pam Donot | Pending | 475 | NA | Maintenance | NA |  |  |
| 110 | 1.1.8.3 | Integral GRP Term Life Ins | 1d | 1996-01-01 | 1996-01-01 | 1930d | finish no earlier than 1996-01-01 | Pam Donot | Pending | 465 | NA | Maintenance | NA |  |  |
| 111 | 1.1.8.4 | Incorrect QPA - Territory Change | 1d | 1996-01-01 | 1996-01-01 | 1930d | finish no earlier than 1996-01-01 | Pam Donot | Pending | 472 | NA | Maintenance | NA |  |  |
| 112 | 1.1.8.5 | INACTIVE PROJECTS Backlog | 1537d | 1994-02-10 | 1999-12-31 | 886d | start no earlier than 1994-02-10 | Pam Donot | Pending | ZZZ9798 | NA | Maintenance Backlog | NA | IT |  |
| 113 | 1.1.8.6 | F&I Internet Plan | 1d | 1996-01-01 | 1996-01-01 | 1930d | finish no earlier than 1996-01-01 | Sandra Sanderson | Pending | 437 | NA | BFI-F&I Infrastructure | NA | F&I |  |
| 114 | 1.1.8.7 | Fix For Fira | 1d | 1996-01-01 | 1996-01-01 | 1930d | finish no earlier than 1996-01-01 | Pam Donot | Pending | 476 | NA | Maintenance | NA |  |  |
| 115 | 1.1.8.8 | Farmer's Project | 1d | 1996-01-01 | 1996-01-01 | 1930d | finish no earlier than 1996-01-01 | Lee George | Pending | 438 | NA | PP-Proposal | NA | F&I |  |
| 116 | 1.1.8.9 | FIRA Adjustments-TYPE 3 | 1d | 1996-01-01 | 1996-01-01 | 1930d | finish no earlier than 1996-01-01 | Pam Donot | Pending | 477 | NA | Maintenance | NA |  |  |
| 117 | 1.1.8.10 | Catalog Production Backup Files | 1d | 1996-01-01 | 1996-01-01 | 1930d | finish no earlier than 1996-01-01 | Pam Donot | Pending | 468 | NA | Maintenance | NA |  |  |
| 118 | 1.1.8.11 | Cash Balance Data | 1d | 1996-01-01 | 1996-01-01 | 1930d | finish no earlier than 1996-01-01 | Pam Donot | Pending | 467 | NA | Maintenance | NA |  |  |
| 119 | 1.1.8.12 | Bridge ICAP to CMS | 1d | 1996-01-01 | 1996-01-01 | 1930d | finish no earlier than 1996-01-01 | Lee Richards | Pending | 447 | NA | PP-Proposal | NA | F&I | ShellyBuchannan |
| 120 | 1.1.8.13 | Breakup PAY0706 | 1d | 1996-01-01 | 1996-01-01 | 1930d | finish no earlier than 1996-01-01 | Pam Donot | Pending | 462 | NA | Maintenance | NA |  |  |
| 121 | 1.1.8.14 | Claims Reorg Efforts | 1d | 1996-01-01 | 1996-01-01 | 1930d | finish no earlier than 1996-01-01 | Betsy Highbrow | Pending | 464 | NA | Maintenance | NA |  |  |
| 122 | 1.1.8.15 | 1099-s for IRS Deadline | 1d | 1996-01-01 | 1996-01-01 | 1930d | finish no earlier than 1996-01-01 | Pam Donot | Pending | 457 | NA | Maintenance | NA |  | Amy Moore |
| 123 | 1.1.8.16 | ACCESS Balancing | 1d | 1996-01-01 | 1996-01-01 | 1930d | finish no earlier than 1996-01-01 | Betsy Highbrow | Pending | 456 | NA | Maintenance | NA |  |  |
| 124 | 1.1.8.17 | Archive old Payroll Sys | 1d | 1996-01-01 | 1996-01-01 | 1930d | finish no earlier than 1996-01-01 | Pam Donot | Pending | 461 | NA | Maintenance | NA |  |  |
| 125 | 1.1.8.18 | Nevada DMV Changes to fix | 1d | 1996-01-01 | 1996-01-01 | 1930d | finish no earlier than 1996-01-01 | Pam Donot | Pending | 459 | NA | Maintenance | NA |  |  |
| 126 | 1.1.8.19 | WC Claim Transfer to ZUS | 1d | 1996-01-01 | 1996-01-01 | 1930d | finish no earlier than 1996-01-01 | Char Valley | Pending | ACS99-001-1 | NA | Maintenance | NA |  | Cathy Stitt |
| 127 | 1.1.8.20 | DSC Cost Analysis | 1d | 1996-01-01 | 1996-01-01 | 1930d | finish no earlier than 1996-01-01 | Lee George | Pending | 441 | NA | PP-Proposal | NA | F&I | ShellyBuchannan |
| 128 | 1.1.8.21 | Vesting Percent Report | 1d | 1996-01-01 | 1996-01-01 | 1930d | finish no earlier than 1996-01-01 | Pam Donot | Pending | 466 | NA | Maintenance | NA |  |  |
| 129 | 1.1.8.22 | Upgrade Rating Capabilities | 1d | 1996-01-01 | 1996-01-01 | 1930d | finish no earlier than 1996-01-01 | Lee George | Pending | 444 | NA | PP-Proposal | NA | F&I | ShellyBuchannan |
| 130 | 1.1.8.23 | Upgrade PC Sponsor System | 1d | 1996-01-01 | 1996-01-01 | 1930d | finish no earlier than 1996-01-01 | Lee George | Pending | 440 | NA | PP-Proposal | NA | F&I | ShellyBuchannan |
| 131 | 1.1.8.24 | Upgrade Sponsor & Policy System | 1d | 1996-01-01 | 1996-01-01 | 1930d | finish no earlier than 1996-01-01 | Lee George | Pending | 448 | NA | PP-Proposal | NA | F&I | ShellyBuchannan |
| 132 | 1.1.8.25 | Upgrade Billing Capabilities | 1d | 1996-01-01 | 1996-01-01 | 1930d | finish no earlier than 1996-01-01 | Lee George | Pending | 439 | NA | PP-Proposal | NA | F&I | ShellyBuchannan |
| 133 | 1.1.8.26 | Thrift Plan -Fund Splits | 1d | 1996-01-01 | 1996-01-01 | 1930d | finish no earlier than 1996-01-01 | Pam Donot | Pending | 478 | NA | Maintenance | NA |  |  |
| 134 | 1.1.8.27 | Payroll Disaster Recovery Plan | 1d | 1996-01-01 | 1996-01-01 | 1930d | finish no earlier than 1996-01-01 | Pam Donot | Pending | 460 | NA | Maintenance | NA |  |  |
| 135 | 1.1.8.28 | PAYDSBT ADJ Run Abend | 1d | 1996-01-01 | 1996-01-01 | 1930d | finish no earlier than 1996-01-01 | Pam Donot | Pending | 463 | NA | Maintenance | NA |  |  |
| 136 | 1.1.8.29 | NV DMV Format Chg (8/2/99) | 1d | 1996-01-01 | 1996-01-01 | 1930d | finish no earlier than 1996-01-01 | Pam Donot | Pending | 458 | NA | Maintenance | NA |  |  |
| 137 | 1.1.8.30 | Missing QPA Amounts | 1d | 1996-01-01 | 1996-01-01 | 1930d | finish no earlier than 1996-01-01 | Pam Donot | Pending | 471 | NA | Maintenance | NA |  |  |
| 138 | 1.1.8.31 | Point of Sale Pilot | 1d | 1996-01-01 | 1996-01-01 | 1930d | finish no earlier than 1996-01-01 | Lee George | Pending | 446 | NA | PP-Proposal | NA | F&I | ShellyBuchannan |
| 139 | 1.1.8.32 | Policy System Feasibility | 1d | 1996-01-01 | 1996-01-01 | 1930d | finish no earlier than 1996-01-01 | Lee George | Pending | 445 | NA | PP-Proposal | NA | F&I | ShellyBuchannan |
| 140 | 1.1.8.33 | Report 369A Acct. exe. Compensat | 1d | 1996-01-01 | 1996-01-01 | 1930d | finish no earlier than 1996-01-01 | Pam Donot | Pending | 474 | NA | Maintenance | NA |  |  |

| ID | WBS | Task | Duration | Start | Finish | Baseline start | Baseline finish | Baseline duration | Total slack | Constraint | Cost | Text1 | Text2 | Text6 | Text7 | Text10 | Text19 | Text20 | Text3 |
| --- | --- | --- | --- | --- | --- | --- | --- | --- | --- | --- | --- | --- | --- | --- | --- | --- | --- | --- | --- |
| 142 | 1.1.9 | **Operations** | 325d | 1998-10-05 | 1999-12-31 |  |  |  | 886d |  | 4,778,630.08 |  |  |  |  |  |  |  |  |
| 143 | 1.1.9.1 | DBA Support | 325d | 1998-10-05 | 1999-12-31 |  |  |  | 886d | start no earlier than 1998-10-05 |  | IT | Herb Clark | Open | MFM0010 | NA | O-Operations | large |  |
| 144 | 1.1.9.2 | ITPM Process Development | 320d | 1998-10-12 | 1999-12-31 | 1998-10-12 | 1999-12-31 | 0d | 886d | start no earlier than 1998-10-12 | 337,723.6 | IT | Mike Riley | Open | OPT0005 | NA | O-Operations | large |  |
| 145 | 1.1.9.3 | Desktop Services | 195d | 1999-04-05 | 1999-12-31 | 1999-04-05 | 1999-12-31 | 0d | 886d | start no earlier than 1999-04-05 | 1,155,000 | IT | Flatnerer/Ricketts | Open | DSK0019 | NA | O-Operations | large |  |
| 146 | 1.1.9.4 | Focus Implementation | 288d | 1998-11-25 | 1999-12-31 | 1998-11-25 | 1999-12-31 | 0d | 886d | start no earlier than 1998-11-25 | 97,271.5 | IT | Myra Svoboda | Open | CLN0003 | NA | O-Operations | large |  |
| 147 | 1.1.9.5 | Mainframe | 195d | 1999-04-05 | 1999-12-31 | 1999-04-05 | 1999-12-31 | 0d | 886d | start no earlier than 1999-04-05 | 94,100 | IT | Joe Rhoads | Open | MFM0008 | NA | O-Operations | large |  |
| 148 | 1.1.9.6 | Special Accounts tasks | 121d | 1999-04-05 | 1999-09-20 | 1999-04-05 | 1999-04-30 | 0d | 960d | start no earlier than 1999-04-05 | 1,296 | IT | Ricketts/Flatnerer | Open | SpAcct99 | NA | O-Operations | med |  |
| 149 | 1.1.9.7 | Viasoft | 294d | 1998-11-17 | 1999-12-31 |  |  |  | 886d | start no earlier than 1998-11-17 |  | IT | Cynthia Moran | Open | VAL0007 | NA | O-Operations | large |  |
| 150 | 1.1.9.8 | Support Center Activities | 280d | 1998-12-07 | 1999-12-31 | 1998-12-07 | 1999-12-31 | 0d | 886d | start no earlier than 1998-12-07 | 895,497.9 | IT | Lisa Wickey | Open | DSK0024 | NA | O-Operations | large |  |
| 151 | 1.1.9.9 | Solutions Support Admin | 293d | 1998-11-18 | 1999-12-31 | 1998-11-18 | 1999-12-31 | 0d | 886d | start no earlier than 1998-11-18 | 666,684.5 | IT | Toni Schmidt | Open | RSE0001 | NA | O-Operations | large |  |
| 152 | 1.1.9.10 | Telephony | 306d | 1998-10-30 | 1999-12-31 | 1998-10-30 | 1998-12-31 | 0d | 886d | start no earlier than 1998-10-30 | 894,250 | IT | Wayne Damon | Open | TEL0013 | NA | O-Operations | large | Russ Jackson |
| 153 | 1.1.9.11 | IS Operations Maintenance | 280d | 1998-12-07 | 1999-12-31 | 1998-12-07 | 1999-12-31 | 0d | 886d | start no earlier than 1998-12-07 | 580,320.83 | IT | Mike Nash | Open | MFM0009 | NA | O-Operations | large |  |
| 154 | 1.1.9.12 | Mgmt/Plan/Control Support | 210d | 1999-03-15 | 1999-12-31 | 1999-03-15 | 1999-12-31 | 0d | 886d | start no earlier than 1999-03-15 | 56,485.75 | IT | Keith Additon | Open | VAL0005 | NA | O-Operations | large |  |
| 156 | 1.1.10 | **Admin** | 1243d | 1998-08-20 | 2003-05-26 |  |  |  | 0d |  | 6,266,399.9 |  |  |  |  |  |  |  |  |
| 157 | 1.1.10.1 | ATG General | 315d | 1998-10-19 | 1999-12-31 |  |  |  | 886d | start no earlier than 1998-10-19 |  | IT | Kevin MacDowell | Open | ADM0005 | NA | A-Administration | large |  |
| 158 | 1.1.10.2 | Business Architect | 240d | 1999-02-01 | 1999-12-31 | 1999-02-02 | 1999-12-31 | 0d | 886d | start no earlier than 1999-02-01 | 328,960 | IT | Debra Landward | Open | ADM0006 | NA | A-Administration | large |  |
| 159 | 1.1.10.3 | Executive Management | 357d | 1998-08-20 | 1999-12-31 | 1998-08-20 | 1999-12-31 | 0d | 886d | start no earlier than 1998-08-20 | 572,836.65 | IT | Mary Hackett | Open | ADM0008 | NA | A-Administration | med |  |
| 160 | 1.1.10.4 | Coach Mtg, Reviews & MISC | 290d | 1998-11-23 | 1999-12-31 |  |  |  | 886d | start no earlier than 1998-11-23 |  | IT | Kathleen Goddard | Open | ADM0009 | NA | A-Administration | large |  |
| 161 | 1.1.10.5 | Management Support Admin | 327d | 1998-10-01 | 1999-12-31 | 1998-10-01 | 1999-12-31 | 0d | 886d | start no earlier than 1998-10-01 | 279,558 | IT | Mary Hackett | Open | ADM0010 | NA | A-Administration | large |  |
| 162 | 1.1.10.6 | Operations Admin | 240d | 1999-02-01 | 1999-12-31 | 1999-02-04 | 1999-12-31 | 0d | 886d | start no earlier than 1999-02-01 | 100,100 | IT | Joe Anderson | Open | ADM0011 | NA | A-Administration | large |  |
| 163 | 1.1.10.7 | Project Office Admin | 321d | 1998-10-09 | 1999-12-31 | 1998-10-09 | 1999-12-31 | 0d | 886d | start no earlier than 1998-10-09 | 567,347.25 | IT | Mary Hackett | Open | ADM0012 | NA | A-Administration | large |  |
| 164 | 1.1.10.8 | Enterprise Applic. Admin. | 255d | 1999-01-11 | 1999-12-31 | 1999-01-11 | 1999-12-31 | 0d | 886d | start no earlier than 1999-01-11 | 345,801 | IT | Judy Dodger | Open | ADM0013 | NA | A-Administration | large |  |
| 165 | 1.1.10.9 | Business Analysts 99 | 322d | 1999-02-01 | 2000-04-25 | 1999-02-01 | 2000-04-25 | 0d | 804d | start no earlier than 1999-02-01 | 237,289.5 | IT | Doug Arnone | Open | CLN0001 | NA | A-Administration | large |  |
| 166 | 1.1.10.10 | EBS Consulting | 192d | 1999-04-08 | 1999-12-31 | 1999-04-08 | 1999-12-31 | 0d | 886d | start no earlier than 1999-04-08 | 78,868.5 | IT | Lee Richards | Open | CLN0002 | NA | A-Administration | large |  |
| 167 | 1.1.10.11 | Business Client Consultant | 1207d | 1998-10-09 | 2003-05-26 | 1998-10-09 | 2003-05-26 | 0d | 0d | start no earlier than 1998-10-09 | 367,645.5 | IT | Lee Richards | Open | CLN0004 | NA | A-Administration | large |  |
| 168 | 1.1.10.12 | Desktop/Telephony Admin/Mgm | 294d | 1998-11-23 | 2000-01-06 | 1998-11-23 | 2000-01-06 | 0d | 882d | start no earlier than 1998-11-23 | 179,747.6 | IT | Jeanne Flatnerer/Wayne Damon | Open | DSA9899 | NA | A-Administration | large |  |
| 169 | 1.1.10.13 | Network Systems Admin. | 305d | 1998-11-02 | 1999-12-31 | 1998-11-02 | 1999-12-31 | 0d | 886d | start no earlier than 1998-11-02 | 1,081,040.1 | IT | Kelly Witte | Open | NWK0023 | NA | A-Administration | large |  |
| 170 | 1.1.10.14 | Architecture Management | 235d | 1999-02-08 | 1999-12-31 | 1999-02-08 | 1999-12-31 | 0d | 886d | start no earlier than 1999-02-08 | 115,891.5 | IT | Craig Lillis | Open | OPT0001 | NA | A-Administration | large |  |
| 171 | 1.1.10.15 | Coach | 261d | 1999-01-04 | 2000-01-03 | 1999-01-04 | 1999-12-31 | 0d | 885d | start no earlier than 1999-01-04 | 629,552 | IT | Nancy Craig | Open | STF0003 | NA | A-Administration | large |  |
| 172 | 1.1.10.16 | SEPG Project | 197d | 1999-04-01 | 1999-12-31 | 1999-04-02 | 1999-12-31 | 0d | 886d | start no earlier than 1999-04-01 | 132,732 | IT | Nancy Craig | Open | STF0006 | NA | A-Administration | large | Russ Jackson |
| 173 | 1.1.10.17 | Non-Project Tasks | 195d | 1999-04-05 | 1999-12-31 | 1999-04-05 | 1999-12-31 | 0d | 886d | start no earlier than 1999-04-05 | 901,394.4 | IT | Kathleen Goddard | Open | STF0007 | NA | A-Administration | large |  |
| 174 | 1.1.10.18 | Skills Assessment | 61d | 1999-08-09 | 1999-11-01 | 1999-08-08 | 1999-11-01 | 0d | 930d | start no earlier than 1999-08-08 | 42,454.2 | IT | Donna Smaty | Open | STF0008 | NA | A-Administration | med |  |
| 175 | 1.1.10.19 | Vendor Management | 334d | 1998-10-19 | 2000-01-27 | 1998-10-19 | 2000-01-07 | 0d | 867d | start no earlier than 1998-10-19 | 305,181.7 | IT | Jack Viers | Open | VAL0008 | NA | A-Administration | large |  |

| ID | WBS | Task | Duration | Start | Finish | Baseline start | Baseline finish | Baseline duration | Total slack | Constraint | Cost | Text1 | Text2 | Text6 | Text7 | Text10 | Text19 | Text20 | Text3 |
| --- | --- | --- | --- | --- | --- | --- | --- | --- | --- | --- | --- | --- | --- | --- | --- | --- | --- | --- | --- |
| 177 | 1.1.11 | **Education** | 386d | 1999-01-04 | 2000-06-26 |  |  |  | 760d |  | 414,200 |  |  |  |  |  |  |  |  |
| 178 | 1.1.11.1 | IT Training | 260d | 1999-01-04 | 1999-12-31 | 1999-01-04 | 1999-12-31 | 0d | 886d | start no earlier than 1999-01-04 | 291,225.6 | IT | Donna Smaty | Open | STF0001 | NA | E-Education | large |  |
| 179 | 1.1.11.2 | EDU-Admin | 381d | 1999-01-11 | 2000-06-26 | 1999-01-11 | 2000-06-26 | 0d | 760d | start no earlier than 1999-01-11 | 110,440.8 | IT | Donna Smaty | Open | STF0004 | NA | E-Education | large |  |
| 180 | 1.1.11.3 | People-CMM | 245d | 1999-01-25 | 1999-12-31 | 1999-01-25 | 1999-12-31 | 0d | 886d | start no earlier than 1999-01-25 | 12,533.6 | IT | Donna Smaty | Open | STF0005 | NA | E-Education | large |  |
| 182 | 1.2 | **1999 Complete** | 511d | 1998-02-02 | 2000-01-17 |  |  |  | 875d |  | 2,596,356.25 |  |  |  |  |  |  |  |  |
| 183 | 1.2.1 | **Y2K** | 511d | 1998-02-02 | 2000-01-17 |  |  |  | 875d |  | 2,112,595.45 |  |  |  |  |  |  |  |  |
| 184 | 1.2.1.1 | Y2K ZSoft Upgrade | 153d | 1998-10-21 | 1999-05-21 | 1998-10-21 | 1999-12-14 | 0d | 1046d | start no earlier than 1998-10-21 | 105,012 | IT | Terri Hitter | Complete | Y2K0007 | NA | P-Major | large | Roger Bishop |
| 185 | 1.2.1.2 | Y2K VSC Retro | 87d | 1998-11-23 | 1999-03-23 | 1998-11-23 | 1999-05-24 | 0d | 1089d | start no earlier than 1998-11-23 | 13,230 | IT | Mike Damon | Complete | Y2K0018 | NA | P-Major | large | David Ryan |
| 186 | 1.2.1.3 | Y2K Cover (Phase II) | 178d | 1998-11-25 | 1999-07-30 | 1998-11-25 | 1999-12-31 | 0d | 996d | start no earlier than 1998-11-25 | 318,326.4 | IT | Wyette Runyan | Complete | Y2K0014 | NA | P-Major | large | Barry Morris |
| 187 | 1.2.1.4 | Y2K Texas Cover V | 371d | 1998-02-02 | 1999-07-05 | 1998-02-02 | 1999-05-17 | 0d | 1015d | start no earlier than 1998-02-02 | 318,023 | P&C | Shelly Sample | Complete | UNI0005 | NA | P-Major | large | Jane Hunley |
| 188 | 1.2.1.5 | Y2K TelCom | 260d | 1998-09-10 | 1999-09-08 | 1998-09-10 | 1999-07-01 | 0d | 968d | start no earlier than 1998-09-10 | 8,560 | IT | Wayne Damon | Complete | Y2K0025 | NA | P-Major | large | Roger Bishop |
| 189 | 1.2.1.6 | Y2K Phase IV | 210d | 1998-11-23 | 1999-09-10 | 1998-11-23 | 1999-08-02 | 0d | 966d | start no earlier than 1998-11-23 | 314,544.5 | IT | Mike Damon | Complete | Y2K0010 | NA | P-Major | large | Carolyn Howell |
| 190 | 1.2.1.7 | Y2K Phase III Drafts | 161d | 1998-11-30 | 1999-07-12 | 1998-11-30 | 1999-03-01 | 0d | 1010d | start no earlier than 1998-11-30 | 35,235 | IT | Mike Damon | Complete | Y2K0011 | NA | P-Major | large | Howell/Ryan |
| 191 | 1.2.1.8 | Workers Compensation | 313d | 1998-10-21 | 1999-12-31 | 1998-10-21 | 1999-05-28 | 0d | 886d | start no earlier than 1998-10-21 | 212,252 | IT | Skip Janis | Complete | Y2K0006 | NA | P-Major | large | Joan Taylor |
| 192 | 1.2.1.9 | Y2K AP/GL | 132d | 1999-03-01 | 1999-08-31 | 1999-03-01 | 1999-09-07 | 0d | 974d | start no earlier than 1999-03-01 | 160,194 | IT | Mike Damon | Complete | Y2K0021 | NA | P-Major | med | Colette Ruble/Janet VanNess |
| 193 | 1.2.1.10 | Y2K AS400 | 231d | 1999-03-01 | 2000-01-17 | 1999-03-01 | 1999-11-12 | 0d | 875d | start no earlier than 1999-03-01 | 97,644.45 | IT | Wayne Damon | Complete | Y2K0022 | NA | P-Major | large | Roger Bishop |
| 194 | 1.2.1.11 | Y2K Phase 1-FINAl2 | 213d | 1998-09-24 | 1999-07-19 | 1998-09-24 | 1999-04-29 | 0d | 1005d | start no earlier than 1998-09-24 | 337,710.8 | IT | Mike Damon | Complete | Y2K0008 | NA | P-Major | large | Carolyn Howell |
| 195 | 1.2.1.12 | Y2K Phase 1-FINAl3 | 214d | 1998-07-15 | 1999-05-10 | 1998-07-15 | 1999-03-02 | 0d | 1055d | start no earlier than 1998-07-15 | 101,217.5 | IT | Mike Damon | Complete | Y2K0009 | NA | P-Major | large | Carolyn Howell |
| 196 | 1.2.1.13 | Y2K MSP Cash | 45d | 1999-07-26 | 1999-09-24 | 1999-07-26 | 1999-09-24 | 0d | 956d | start no earlier than 1999-07-26 | 9,303 | Accounti | Mike Damon | Complete | Y2K0029 | NA | P-Major | small | Janet Van Ness |
| 197 | 1.2.1.14 | Y2K CICS 4.1 Project | 175d | 1998-10-26 | 1999-06-25 | 1998-10-26 | 1999-06-01 | 0d | 1021d | start no earlier than 1998-10-26 | 34,030.8 | IT | Kevin Jackson | Complete | Y2K0005 | NA | P-Major | large | Jackson/Smith |
| 198 | 1.2.1.15 | DADS Project | 158d | 1998-10-29 | 1999-06-07 | 1998-10-29 | 1999-06-07 | 0d | 1035d | start no earlier than 1998-10-29 | 22,580 | IT | Kevin Jackson | Complete | Y2K0019 | NA | P-Major | large | Russ Jackson |
| 199 | 1.2.1.16 | Z-Soft Production Support | 132d | 1998-11-30 | 1999-06-01 | 1998-11-30 | 1999-05-03 | 0d | 1039d | start no earlier than 1998-11-30 | 24,732 | IT | Terri Hitter | Complete | Y2K0026 | NA | Support | large | Lucy Witt |
| 201 | 1.2.2 | **Atlantis** | 141d | 1998-12-28 | 1999-07-12 |  |  |  | 1010d |  |  |  |  |  |  |  |  |  |  |
| 202 | 1.2.2.1 | Atlantis Laptop Deploy Guide | 141d | 1998-12-28 | 1999-07-12 |  |  |  | 1010d | start no earlier than 1998-12-28 |  | ASMPS | Doug Arnone | Complete | CPC0005 | NA | P-Major | large | Bill Whitney |

| ID | WBS | Task | Duration | Start | Finish | Baseline start | Baseline finish | Baseline duration | Total slack | Constraint | Cost | Text1 | Text2 | Text3 | Text6 | Text7 | Text10 | Text19 | Text20 |
| --- | --- | --- | --- | --- | --- | --- | --- | --- | --- | --- | --- | --- | --- | --- | --- | --- | --- | --- | --- |
| 204 | 1.2.3 | **Small** | 16d | 1999-07-19 | 1999-08-09 |  |  |  | 990d |  |  |  |  |  |  |  |  |  |  |
| 205 | 1.2.3.1 | VSC GTAM | 16d | 1999-07-19 | 1999-08-09 |  |  |  | 990d | start no earlier than 1999-07-19 |  | VSC | Lisa Doright | Linda Sigloch | Complete | ESC0008 | NA | Small | small |
| 207 | 1.2.4 | **Infrastructure** | 369d | 1998-04-22 | 1999-09-20 |  |  |  | 960d |  | 358,818 |  |  |  |  |  |  |  |  |
| 208 | 1.2.4.1 | IT Request Service | 162d | 1999-02-05 | 1999-09-20 |  |  |  | 960d | start no earlier than 1999-02-05 |  | IT | Judy Dodger | Lucy Witt | Complete | OPT0002 | NA | I-Infrastructure | med |
| 209 | 1.2.4.2 | Internet Tasks | 170d | 1998-10-20 | 1999-06-14 | 1998-10-20 | 1999-06-14 | 0d | 1030d | start no earlier than 1998-10-20 | 65 | IT | Judy Dodger | Lucy Witt | Complete | ITN0005 | NA | I-Infrastructure | large |
| 210 | 1.2.4.3 | FTP Implementation | 171d | 1998-09-14 | 1999-05-10 | 1998-09-14 | 1999-04-26 | 0d | 1055d | start no earlier than 1998-09-14 | 58,647.75 | IT | Neil Giggnot | Peter Smith | Complete | ITN0001 | NA | I-Infrastructure | large |
| 211 | 1.2.4.4 | CD-R Drive System | 4d | 1998-12-28 | 1998-12-31 |  |  |  | 1147d | start no earlier than 1998-12-28 |  | IT | Doug Arnone | Lucy Witt | Complete | DSK0021 | NA | I-Infrastructure |  |
| 212 | 1.2.4.5 | KC Lucent | 89d | 1999-04-13 | 1999-08-13 | 1999-04-13 | 1999-06-04 | 0d | 986d | start no earlier than 1999-04-13 | 6,099.5 | IT | Wayne Damon | Jack Tschippert | Complete | KCL0001 | NA | I-Infrastructure | med |
| 213 | 1.2.4.6 | Web 'The Specialist' | 90d | 1999-01-20 | 1999-05-25 |  |  |  | 1044d | start no earlier than 1999-01-20 |  | Ins Dealer | Judy Dodger | Mark Smith | Complete | ITN0007 | NA | I-Infrastructure | med |
| 214 | 1.2.4.7 | Upgrade Celerity Software | 223d | 1998-11-12 | 1999-09-20 | 1998-11-12 | 1999-03-15 | 0d | 960d | start no earlier than 1998-11-12 | 5,400 | IT | Kelly Witte | Lucy Witt | Complete | UNI0002 | NA | I-Infrastructure | large |
| 215 | 1.2.4.8 | SAS Web Page Update | 25d | 1999-03-08 | 1999-04-09 |  |  |  | 1076d | start no earlier than 1999-03-08 |  | Special | Lisa Doright | Cecelia Snodgrass | Complete | ITN0006 | NA | I-Infrastructure | small |
| 216 | 1.2.4.9 | RACF Conversion | 76d | 1999-01-04 | 1999-04-19 |  |  |  | 1070d | start no earlier than 1999-01-04 |  | IT | Joe Rhoads | Lucy Witt | Complete | VAL0006 | NA | I-Infrastructure | med |
| 217 | 1.2.4.10 | Remoteware Implementation | 269d | 1998-04-22 | 1999-05-03 | 1998-04-22 | 1999-03-05 | 0d | 1060d | start no earlier than 1998-04-22 | 125,413.75 | ASMPS | Neil Giggnot | Bill Whitney | Complete | E70098 | NA | P-Infrastructure | large |
| 218 | 1.2.4.11 | ABT Results Management | 140d | 1998-07-14 | 1999-01-25 | 1998-07-14 | 1998-09-29 | 0d | 1130d | start no earlier than 1998-07-14 | 163,192 | IT | Mary Hackett | Peter Smith | Complete | OPT0004 | NA | P-Major | large |
| 220 | 1.2.5 | **Maintenance** | 164d | 1999-01-11 | 1999-08-26 |  |  |  | 977d |  | 124,942.8 |  |  |  |  |  |  |  |  |
| 221 | 1.2.5.1 | Convert Matrix tables to DB | 38d | 1999-07-01 | 1999-08-23 |  |  |  | 980d | start no earlier than 1999-07-01 |  | F&I | Lisa Doright | Linda Sigloch | Complete | ESC0005 | NA | P-Maintenance | small |
| 222 | 1.2.5.2 | VSC99 | 164d | 1999-01-11 | 1999-08-26 | 1999-01-11 | 1999-06-25 | 0d | 977d | start no earlier than 1999-01-11 | 124,942.8 | IT | Lisa Doright | Betti Johnson | Complete | ESC0007 | NA | P-Maintenance | large |
| 224 | 1.3 | **1999 Closed** | 593d | 1997-09-24 | 1999-12-31 |  |  |  | 886d |  | 1,230,315.62 |  |  |  |  |  |  |  |  |
| 225 | 1.3.1 | **Y2K** | 414d | 1997-09-24 | 1999-04-26 |  |  |  | 1065d |  | 334,717.87 | IT | Kelly Enrich | Roger Jones |  |  |  |  |  |
| 226 | 1.3.1.1 | Y2K AS 400 Reg Office 2 | 109d | 1998-11-02 | 1999-04-01 | 1998-11-02 | 1999-04-01 | 0d | 1082d | start no earlier than 1998-11-02 | 32,929 | IT | Kelly Witte | Roger Jones | Closed | Y2K0002 | NA | P-Major | large |
| 227 | 1.3.1.2 | Y2K PC Applications (X) | 414d | 1997-09-24 | 1999-04-26 | 1997-09-24 | 1999-03-26 | 0d | 1065d | start no earlier than 1997-09-24 | 301,788.87 | IT | Jonny Carson | Roger Jones | Closed | Y2K0012 | NA | P-Major | large |
| 229 | 1.3.2 | **SAP** | 340d | 1998-09-14 | 1999-12-31 |  |  |  | 886d |  | 217,848 |  |  |  |  |  |  |  |  |
| 230 | 1.3.2.1 | NT Batch Scheduler | 191d | 1998-09-14 | 1999-06-07 | 1998-09-14 | 1999-03-01 | 0d | 1035d | start no earlier than 1998-09-14 | 51,964.5 | IT | Neil Giggnot | Cindy Mee | Closed | SAP0001 | NA | I-Infrastructure | large |
| 231 | 1.3.2.2 | NT Rollout - SAP | 275d | 1998-12-14 | 1999-12-31 | 1998-12-14 | 1999-12-31 | 0d | 886d | start no earlier than 1998-12-14 | 165,883.5 | IT | Lee Hopkins | Cindy Mee | Closed | SAP0004 | NA | P-Major | large |

| ID | WBS | Task | Duration | Start | Finish | Baseline start | Baseline finish | Baseline duration | Total slack | Constraint | Cost | Text1 | Text2 | Text3 | Text6 | Text7 | Text10 | Text19 | Text20 |
| --- | --- | --- | --- | --- | --- | --- | --- | --- | --- | --- | --- | --- | --- | --- | --- | --- | --- | --- | --- |
| 233 | 1.3.3 | **Atlantis** | 248d | 1998-12-10 | 1999-11-22 |  |  |  | 915d |  | 411,915.25 |  |  |  |  |  |  |  |  |
| 234 | 1.3.3.1 | Sybase Framework | 211d | 1999-02-01 | 1999-11-22 | 1999-02-01 | 1999-10-25 | 0d | 915d | start no earlier than 1999-02-01 | 159,076.5 | ASMPS | George Hawks | Bill Whitney | Closed | CPC0003 | NA | P-Infrastructure | large |
| 235 | 1.3.3.2 | OM&PR | 140d | 1998-12-10 | 1999-06-23 | 1998-12-10 | 1999-12-31 | 0d | 1023d | start no earlier than 1998-12-10 | 252,838.75 | ASMPS | Neal Goodkind | Joan Taylor | Closed | CPC0004 | NA | P-Infrastructure | large |
| 237 | 1.3.4 | **Small** | 285d | 1998-11-30 | 1999-12-31 |  |  |  | 886d |  | 22,950 |  |  |  |  |  |  |  |  |
| 238 | 1.3.4.1 | Bus Grp-HR | 277d | 1998-12-01 | 1999-12-22 |  |  |  | 893d | start no earlier than 1998-12-01 |  | HR | Jeanne Flatnerer/Damon | Sam Lostit | Closed | HR9899 | NA | PS-Department | large |
| 239 | 1.3.4.2 | Bus Grp-ZZZZ | 284d | 1998-12-01 | 1999-12-31 |  |  |  | 886d | start no earlier than 1998-12-01 |  | IT | Jeanne Flatnerer/Wayne Damon | Sam Lostit | Closed | ZPI9899 | NA | PS-Department | large |
| 240 | 1.3.4.3 | Bus Grp-AC | 284d | 1998-12-01 | 1999-12-31 |  |  |  | 886d | start no earlier than 1998-12-01 |  | IT | Jeanne Flatnerer/Wayne Damon | Sam Lostit | Closed | UUAC9899 | NA | PS-Department | large |
| 241 | 1.3.4.4 | Bus Grp-SALVAGE | 285d | 1998-11-30 | 1999-12-31 |  |  |  | 886d | start no earlier than 1998-11-30 |  | IT | Jeanne Flatnerer/Wayne Damon | Sam Lostit | Closed | SALV9899 | NA | PS-Department | large |
| 242 | 1.3.4.5 | Bus Grp-SA | 285d | 1998-11-30 | 1999-12-31 | 1999-03-01 | 1999-04-30 | 0d | 886d | start no earlier than 1998-11-30 | 2,160 | IT | Jeanne Flatnerer/Wayne Damon | Sam Lostit | Closed | SA9899 | NA | PS-Department | large |
| 243 | 1.3.4.6 | Bus Grp-LEGAL | 284d | 1998-12-01 | 1999-12-31 | 1999-02-02 | 1999-12-31 | 0d | 886d | start no earlier than 1998-12-01 | 10,800 | Legal | Jeanne Flatnerer/Wayne Damon | Sam Lostit | Closed | LGL9899 | NA | PS-Department | large |
| 244 | 1.3.4.7 | Bus Grp-GTS | 284d | 1998-12-01 | 1999-12-31 |  |  |  | 886d | start no earlier than 1998-12-01 |  | IT | Jeanne Flatnerer/Wayne Damon | Sam Lostit | Closed | GTS9899 | NA | PS-Department | large |
| 245 | 1.3.4.8 | Bus Grp-F&ICL | 284d | 1998-12-01 | 1999-12-31 | 1999-03-19 | 1999-04-28 | 0d | 886d | start no earlier than 1998-12-01 | 2,700 | F&I | Jeanne Flatnerer/Wayne Damon | Sam Lostit | Closed | FICL9899 | NA | PS-Department | large |
| 246 | 1.3.4.9 | Bus Grp-IT | 285d | 1998-11-30 | 1999-12-31 | 1999-02-03 | 1999-02-15 | 0d | 886d | start no earlier than 1998-11-30 | 540 | IT | Jeanne Flatnerer/Wayne Damon | Sam Lostit | Closed | IS9899 | NA | PS-Department | large |
| 247 | 1.3.4.10 | Bus Grp-DLRW | 284d | 1998-12-01 | 1999-12-31 |  |  |  | 886d | start no earlier than 1998-12-01 |  | Ins Dealer | Jeanne Flatnerer/Wayne Damon | Sam Lostit | Closed | DLRW9899 | NA | PS-Department | large |
| 248 | 1.3.4.11 | Bus Grp-DLRS | 284d | 1998-12-01 | 1999-12-31 |  |  |  | 886d | start no earlier than 1998-12-01 |  | Ins Dealer | Jeanne Flatnerer/Wayne Damon | Sam Lostit | Closed | DLRS9899 | NA | PS-Department | large |
| 249 | 1.3.4.12 | Bus Grp-DLRN | 284d | 1998-12-01 | 1999-12-31 |  |  |  | 886d | start no earlier than 1998-12-01 |  | Ins Dealer | Jeanne Flatnerer/Wayne Damon | Sam Lostit | Closed | DLRN9899 | NA | PS-Department | large |
| 250 | 1.3.4.13 | Bus Grp-DLRE | 284d | 1998-12-01 | 1999-12-31 |  |  |  | 886d | start no earlier than 1998-12-01 |  | Ins Dealer | Jeanne Flatnerer/Wayne Damon | Sam Lostit | Closed | DLRE9899 | NA | PS-Department | large |
| 251 | 1.3.4.14 | Bus Grp-DLRC | 284d | 1998-12-01 | 1999-12-31 |  |  |  | 886d | start no earlier than 1998-12-01 |  | Ins Dealer | Jeanne Flatnerer/Wayne Damon | Sam Lostit | Closed | DLRC9899 | NA | PS-Department | large |
| 252 | 1.3.4.15 | Bus Grp-CD COMM | 277d | 1998-12-01 | 1999-12-22 |  |  |  | 893d | start no earlier than 1998-12-01 |  | Corp Dev | Jeanne Flatnerer/Damon | Sam Lostit | Closed | CDCOM99 | NA | PS-Department | large |
| 253 | 1.3.4.16 | Bus Grp-Audit | 284d | 1998-12-01 | 1999-12-31 |  |  |  | 886d | start no earlier than 1998-12-01 |  | Audit | Jeanne Flatnerer/Wayne Damon | Sam Lostit | Closed | AUD9899 | NA | PS-Department | large |
| 254 | 1.3.4.17 | Bus Grp-ASM | 284d | 1998-12-01 | 1999-12-31 |  |  |  | 886d | start no earlier than 1998-12-01 |  | ASMPS | Jeanne Flatnerer/Wayne Damon | Sam Lostit | Closed | ASM9899 | NA | PS-Department | large |
| 255 | 1.3.4.18 | Bus Grp -Accounting | 285d | 1998-11-30 | 1999-12-31 | 1999-02-03 | 1999-04-01 | 0d | 886d | start no earlier than 1998-11-30 | 6,750 | Accounting | Jeanne Flatnerer/Wayne Damon | Sam Lostit | Closed | ACCT9899 | NA | PS-Department | large |
| 256 | 1.3.4.19 | Bus Grp-PCSVD | 285d | 1998-11-30 | 1999-12-31 |  |  |  | 886d | start no earlier than 1998-11-30 |  | IT | Jeanne Flatnerer/Wayne Damon | Sam Lostit | Closed | PCSV9899 | NA | PS-Department | large |
| 257 | 1.3.4.20 | Bus Grp. IT | 210d | 1999-03-15 | 1999-12-31 |  |  |  | 886d | start no earlier than 1999-03-15 |  | IT | Tim Rodgers | Sam Lostit | Closed | DETS99 | NA | SM-Department | large |
| 258 | 1.3.4.21 | D-P&C Services | 220d | 1999-03-01 | 1999-12-31 |  |  |  | 886d | start no earlier than 1999-03-01 |  | P&C | Tim Rodgers | Sam Lostit | Closed | DPCS | NA | SM-Department | large |

| ID | WBS | Task | Duration | Start | Finish | Baseline start | Baseline finish | Baseline duration | Total slack | Constraint | Cost | Text1 | Text2 | Text3 | Text6 | Text7 | Text10 | Text19 | Text20 |
| --- | --- | --- | --- | --- | --- | --- | --- | --- | --- | --- | --- | --- | --- | --- | --- | --- | --- | --- | --- |
| 260 | 1.3.5 | **Infrastructure** | 356d | 1998-08-21 | 1999-12-31 |  |  |  | 886d |  | 157,561 |  |  |  |  |  |  |  |  |
| 261 | 1.3.5.1 | Disaster Recovery | 232d | 1998-08-21 | 1999-07-12 | 1998-08-21 | 1999-01-29 | 0d | 1010d | start no earlier than 1998-08-21 |  | IT | Mike Damon | Jonas Kowton | Closed | NWK0022 | NA | I-Infrastructure | large |
| 262 | 1.3.5.2 | Investigate 11 CD Roms | 59d | 1998-11-11 | 1999-02-01 |  |  |  | 1125d | start no earlier than 1998-11-11 |  | IT | Kelly Witte | Jonas Kowton | Closed | E80897 | NA | I-Infrastructure | large |
| 263 | 1.3.5.3 | Install Fleet Software | 46d | 1998-12-21 | 1999-02-22 |  |  |  | 1110d | start no earlier than 1998-12-21 |  | P&C | Tim Culley | Jonas Kowton | Closed | DPR0001 | NA | I-Infrastructure | large |
| 264 | 1.3.5.4 | Coin Upgrade | 142d | 1998-11-11 | 1999-05-27 |  |  |  | 1042d | start no earlier than 1998-11-11 |  | IT | Kelly Witte | Jonas Kowton | Closed | UAC0002 | NA | I-Infrastructure | large |
| 265 | 1.3.5.5 | Colossus Injury System | 81d | 1998-12-21 | 1999-04-12 |  |  |  | 1075d | start no earlier than 1998-12-21 |  | DLT | Doug Arnone | Jonas Kowton | Closed | CMS0002 | NA | I-Infrastructure | large |
| 266 | 1.3.5.6 | Conversion of RPIGH | 229d | 1998-11-04 | 1999-09-20 | 1999-03-29 | 1999-06-30 | 0d | 960d | start no earlier than 1998-11-04 | 13,500 | DLT | Kelly Witte | Jonas Kowton | Closed | BLG0007 | NA | I-Infrastructure | large |
| 267 | 1.3.5.7 | SAA Gateway printing | 61d | 1998-11-09 | 1999-02-01 |  |  |  | 1125d | start no earlier than 1998-11-09 |  | AC | Kelly Witte | Jonas Kowton | Closed | BLG0005 | NA | I-Infrastructure | large |
| 268 | 1.3.5.8 | New Building Move Project | 90d | 1998-11-02 | 1999-03-05 |  |  |  | 1101d | start no earlier than 1998-11-02 |  | IT | Kelly Witte | Jonas Kowton | Closed | BLG0004 | NA | I-Infrastructure | large |
| 269 | 1.3.5.9 | Norton Antivirus | 48d | 1998-12-10 | 1999-02-15 |  |  |  | 1115d | start no earlier than 1998-12-10 |  | IT | Tim Culley | Jonas Kowton | Closed | DSK0022 | NA | I-Infrastructure | large |
| 270 | 1.3.5.10 | Lotus Notes/Regional Office | 221d | 1998-11-16 | 1999-09-20 | 1998-11-16 | 1999-08-02 | 0d | 960d | start no earlier than 1998-11-16 | 78,300 | IT | Kelly Witte | Jonas Kowton | Closed | VAL0004 | NA | I-Infrastructure | large |
| 271 | 1.3.5.11 | Migrate UMB function - 3745 | 125d | 1999-01-18 | 1999-07-09 | 1999-01-18 | 1999-06-01 | 0d | 1011d | start no earlier than 1999-01-18 | 5,724 | IT | Kelly Witte | Jonas Kowton | Closed | BLG0003 | NA | I-Infrastructure | large |
| 272 | 1.3.5.12 | ZTS Internet Server | 314d | 1998-10-20 | 1999-12-31 |  |  |  | 886d | start no earlier than 1998-10-20 |  | IT | Judy Dodger | Jonas Kowton | Closed | ITN0008 | NA | I-Infrastructure | large |
| 273 | 1.3.5.13 | RAD Group Projects | 275d | 1998-12-14 | 1999-12-31 |  |  |  | 886d | start no earlier than 1998-12-14 |  | IT | Judy Dodger | Jonas Kowton | Closed | ITN0009 | NA | I-Infrastructure | large |
| 274 | 1.3.5.14 | Relocate 3745 to megacenter | 57d | 1998-11-13 | 1999-02-01 |  |  |  | 1125d | start no earlier than 1998-11-13 |  | IT | Kelly Witte | Jonas Kowton | Closed | VAL0001 | NA | I-Infrastructure | large |
| 275 | 1.3.5.15 | Resource Manager | 43d | 1999-05-27 | 1999-07-26 |  |  |  | 1000d | start no earlier than 1999-05-27 |  | IT | Lisa Doright | Luke Jones | Closed | OPT0006 | NA | I-Infrastructure | small |
| 276 | 1.3.5.16 | Purchase and instal LEGALEA | 19d | 1999-01-08 | 1999-02-03 |  |  |  | 1123d | start no earlier than 1999-01-08 |  | Ins Ins Dealer | Tim Culley | Basil Lewis | Closed | DLR0001 | NA | I-Infrastructure | small |
| 277 | 1.3.5.17 | Peregrine SW Install | 206d | 1998-11-02 | 1999-08-16 | 1998-11-02 | 1999-05-21 | 0d | 985d | start no earlier than 1998-11-02 | 57,419 | IT | Jay Flatner | Basil Lewis | Closed | TCO0003 | NA | Minor | large |
| 278 | 1.3.5.18 | **Maintenance** | 245d | 1999-01-04 | 1999-12-10 |  |  |  | 901d |  |  | IT | Dave Leslie | Skip Akot |  |  |  |  |  |
| 279 | 1.3.5.18.1 | WorkComp Phase 4(X) | 245d | 1999-01-04 | 1999-12-10 |  |  |  | 901d | start no earlier than 1999-01-04 |  | IT | Skip Janis | Skip Akot | Closed | WCPH4 | NA | P-Major |  |
| 281 | 1.3.5.19 | **Admin** | 284d | 1998-12-01 | 1999-12-31 |  |  |  | 886d |  | 2,618 |  |  |  |  |  |  |  |  |
| 282 | 1.3.5.19.1 | Project Initation Plan | 175d | 1999-05-03 | 1999-12-31 | 1999-05-03 | 1999-12-31 | 0d | 886d | start no earlier than 1999-05-03 | 2,618 | IT | Joe Taylor | Jonas Kowton | Closed | PIP0001 | NA | A-Administration | 10 |
| 283 | 1.3.5.19.2 | Comp.-wide-Desktop/Telephony | 284d | 1998-12-01 | 1999-12-31 |  |  |  | 886d | start no earlier than 1998-12-01 |  | IT | Jeanne Flatnerer/Wayne Damon | Jonas Kowton | Closed | UAD9899 | NA | Support |  |
| 285 | 1.3.6 | **Suspended** | 285d | 1998-09-01 | 1999-10-04 |  |  |  | 950d |  | 85,323.5 |  |  |  |  |  |  |  |  |
| 286 | 1.3.6.1 | Los Angeles Move | 131d | 1999-04-05 | 1999-10-04 |  |  |  | 950d | start no earlier than 1999-04-05 |  | IT | Wayne Damon | Eisenberg | Suspended | ADM0007 | NA | P-Infrastructure | med |
| 287 | 1.3.6.2 | Windows NT Deployment | 26d | 1999-04-05 | 1999-05-10 | 1999-04-05 | 1999-05-10 | 0d | 1055d | start no earlier than 1999-04-05 | 7,815.5 | IT | Jonny Carson | Peter Smith | Suspended | WNTD499 | NA | I-Infrastructure | small |
| 288 | 1.3.6.3 | AAA - STAR | 121d | 1999-03-25 | 1999-09-09 |  |  |  | 967d | start no earlier than 1999-03-25 |  | IT | Kevin Jackson | Kate Token | Suspended | UNI0008 | NA | Maintenance | med |
| 289 | 1.3.6.4 | Y2K Testing ACCESS | 185d | 1998-09-01 | 1999-05-17 | 1998-09-01 | 1999-03-01 | 0d | 1050d | start no earlier than 1998-09-01 | 33,102 | IT | Mike Damon | Roger Bishop | Suspended | Y2K0020 | NA | P-Major | large |
| 290 | 1.3.6.5 | Software Metering | 191d | 1998-12-28 | 1999-09-20 | 1998-12-28 | 1999-08-31 | 0d | 960d | start no earlier than 1998-12-28 | 16,200 | IT | Kelly Witte | Kate Token | Suspended | TCO0005 | NA | I-Infrastructure | large |
| 291 | 1.3.6.6 | SERVICE Software Testing/Notes | 223d | 1998-11-12 | 1999-09-20 |  |  |  | 960d | start no earlier than 1998-11-12 |  | Legal | Kelly Witte | Kate Token | Suspended | DLG0001 | NA | I-Infrastructure | large |
| 292 | 1.3.6.7 | Albany Move | 61d | 1999-06-29 | 1999-09-21 | 1999-06-25 | 1999-09-08 | 0d | 959d | start no earlier than 1999-06-29 | 28,206 | Ins Dealer | Wayne Damon | Eisenberg | Suspended | ADM0016 | NA | P-Infrasturcture | med |
